# Schedule

Schedule from MS Project, 2011-02-02 to 2011-06-17.
MBARI

## Calendars

- Standard: Mon-Fri 08:00-12:00, 13:00-17:00; Sat-Sun off.

## Schedule

| ID | WBS | Task | Duration | Start | Finish | Predecessors | Total slack | Free slack | Constraint |
| --- | --- | --- | --- | --- | --- | --- | --- | --- | --- |
| 1 | 1 | Submerged Flapping Foil | 98d? | 2011-02-02 | 2011-06-17 |  | 0d |  | start no earlier than 2011-02-02 |
| 2 | 2 | Requirements Definition | 5d? | 2011-02-02 | 2011-02-08 |  | 93d |  |  |
| 3 | 3 | Concept Design Work | 12d? | 2011-02-02 | 2011-02-17 |  | 0d |  | finish no earlier than 2011-02-17 |
| 4 | 4 | Concept Design Review | 1d? | 2011-02-18 | 2011-02-18 | 3 | 0d |  | finish no earlier than 2011-02-18 |
| 5 | 5 | Design Work | 19d? | 2011-02-21 | 2011-03-17 | 4 | 0d |  | start no earlier than 2011-02-21 |
| 6 | 6 | Design Review | 1d? | 2011-03-18 | 2011-03-18 | 5 | 0d |  | start no earlier than 2011-03-11 |
| 7 | 7 | Fabrication/Integration/Test | 35d? | 2011-03-21 | 2011-05-06 | 6 | 0d |  |  |
| 8 | 8 | Test Deploy #1 | 5d? | 2011-05-09 | 2011-05-13 | 7 | 0d |  | start no earlier than 2011-05-09 |
| 9 | 9 | Refinements | 20d? | 2011-05-16 | 2011-06-10 | 8 | 0d |  | start no earlier than 2011-05-16 |
| 10 | 10 | Test Deploy #2 | 5d? | 2011-06-13 | 2011-06-17 | 9 | 0d |  | start no earlier than 2011-06-13 |
| 13 | 11 | Buoy Design | 98d? | 2011-02-02 | 2011-06-17 |  | 0d |  | start no earlier than 2011-02-02 |
| 14 | 12 | Requirements Definition | 11d? | 2011-02-02 | 2011-02-16 |  | 65d | 0d | finish no earlier than 2011-02-16 |
| 15 | 13 | Requirements Review | 1d? | 2011-02-17 | 2011-02-17 | 14 | 65d | 0d | finish no earlier than 2011-02-17 |
| 16 | 14 | Design Work | 18d? | 2011-02-18 | 2011-03-15 | 15 | 65d | 0d |  |
| 17 | 15 | Design Review | 3d? | 2011-03-16 | 2011-03-18 | 16 | 65d |  | start no earlier than 2011-03-11 |
| 18 | 16 | Fabrication/Integration/Test | 60d? | 2011-03-21 | 2011-06-10 |  | 0d |  | finish no earlier than 2011-06-10 |
| 19 | 17 | Test Deploy #1 | 5d? | 2011-06-13 | 2011-06-17 | 18 | 0d |  | start no earlier than 2011-06-13 |
| 22 | 18 | PTO Development | 98d? | 2011-02-02 | 2011-06-17 |  | 0d |  | start no earlier than 2011-02-02 |
| 23 | 19 | Concept Development | 23d? | 2011-02-02 | 2011-03-04 |  | 74d | 0d | start no earlier than 2011-02-02 |
| 24 | 20 | Concept Design Review | 1d? | 2011-03-07 | 2011-03-07 | 23 | 74d |  | finish no earlier than 2011-03-07 |
| 28 | 21 | Test Machine Demonstration | 20d? | 2011-05-23 | 2011-06-17 |  | 0d |  | start no earlier than 2011-05-23 |
| 33 | 22 | AUV Docking | 98d? | 2011-02-02 | 2011-06-17 |  | 0d |  | start no earlier than 2011-02-02 |
| 34 | 23 | Compilation of Expected Dock Motions | 22d? | 2011-02-02 | 2011-03-03 |  | 40d | 0d |  |
| 35 | 24 | Docking Simulations | 36d? | 2011-03-04 | 2011-04-22 | 34 | 40d |  | finish no earlier than 2011-04-01 |
